# Malware Protection Overhaul Jan02

Schedule from MS Project, 2012-11-05 to 2013-04-05, A marks actual dates.
MIT

## Calendars

- Standard: Mon-Fri 08:00-12:00, 13:00-17:00; Sat-Sun off.

## Resources

| Resource |
| --- |
| Andrew |
| Sophie |
| Richard |
| Tim |

## Schedule

| ID | WBS | Task | Type | Duration | Start | Finish | Complete | Remaining | Total slack | Resources | Work | Actual work |
| --- | --- | --- | --- | --- | --- | --- | --- | --- | --- | --- | --- | --- |
| 1 | 1 | **Malware Protection Overhaul Project** |  | 110d? | 2012-11-05 A | 2013-04-05 | 20% | 87.59d? | 0d |  | 1656h | 87.6h |
| 2 | 1.1 | **Planning** |  | 1d | 2012-11-05 A | 2012-11-05 A | 100% |  |  |  | 24h | 24h |
| 3 | 1.1.1 | Define scope | manual | 1d | 2012-11-05 A | 2012-11-05 A | 100% |  |  | Sophie | 8h | 8h |
| 4 | 1.1.2 | Review scope with Mark | manual | 1d | 2012-11-05 A | 2012-11-05 A | 100% |  |  | Sophie | 8h | 8h |
| 5 | 1.1.3 | Kickoff Meeting - include other teams | manual | 1d | 2012-11-05 A | 2012-11-05 A | 100% |  |  | Sophie | 8h | 8h |
| 6 | 1.2 | **Communications** |  | 1d? | 2012-11-14 A | 2012-11-14 A | 100% |  |  |  | 24h | 24h |
| 7 | 1.2.1 | Initial IT Leader meeting presentation |  | 1d? | 2012-11-14 A | 2012-11-14 A | 100% |  |  | Andrew | 8h | 8h |
| 8 | 1.2.2 | Contact IT Leaders to solicite volunteers for pilot | manual | 1d | 2012-11-14 A | 2012-11-14 A | 100% |  |  | Tim | 8h | 8h |
| 9 | 1.2.3 | Checklist for pilot | manual | 1d | 2012-11-14 A | 2012-11-14 A | 100% |  |  | Andrew | 8h | 8h |
| 10 | 1.3 | **Windows Selection** |  | 103d? | 2012-11-14 A | 2013-04-05 | 16% | 86.52d? | 0d |  | 936h | 27.2h |
| 11 | 1.3.1 | **System Center 2012 (Forefront) Evaluation** |  | 57d? | 2012-11-14 A | 2013-01-31 | 50% | 28.5d? | 0d | Andrew | 472h | 19.2h |
| 12 | 1.3.1.1 | VM setup | manual | 1d | 2012-11-14 A | 2012-11-14 A | 100% |  |  | Richard | 8h | 8h |
| 13 | 1.3.1.2 | Console setup | manual | 1d | 2012-11-14 A | 2012-11-14 A | 100% |  |  | Richard | 8h | 8h |
| 14 | 1.3.1.3 | Console and client functionality evaluation | manual | 1d? | 2013-01-31 | 2013-01-31 |  |  |  |  |  |  |
| 15 | 1.3.1.4 | Document pros and cons | manual | 1d? | 2013-01-31 | 2013-01-31 |  |  |  |  |  |  |
| 16 | 1.3.2 | **ESET Evaluation (v5.0 - Jan 2013)** |  | 57d? | 2012-11-14 A | 2013-01-31 | 75% | 14.25d? | 0d | Andrew | 456h |  |
| 17 | 1.3.2.1 | VM setup | manual | 1d | 2012-11-14 A | 2012-11-14 A | 100% |  |  |  |  |  |
| 18 | 1.3.2.2 | Console setup | manual | 1d | 2012-11-14 A | 2012-11-14 A | 100% |  |  |  |  |  |
| 19 | 1.3.2.3 | Console and client functionality evaluation | manual | 1d | 2012-11-14 A | 2012-11-14 A | 100% |  |  |  |  |  |
| 20 | 1.3.2.4 | Document pros and cons | manual | 1d? | 2013-01-31 | 2013-01-31 |  |  |  |  |  |  |
| 21 | 1.3.3 | **Vendor Demo** |  | 67d | 2012-11-14 A | 2013-02-14 | 7% | 62.21d | 0d |  |  |  |
| 22 | 1.3.3.1 | Determine invitees | manual | 1d | 2012-11-14 A | 2012-11-14 A | 100% |  |  |  |  |  |
| 23 | 1.3.3.2 | Determine requirements | manual | 1d | 2013-02-01 | 2013-02-01 |  |  |  |  |  |  |
| 24 | 1.3.3.3 | Demo | manual | 10d | 2013-02-01 | 2013-02-14 |  |  |  |  |  |  |
| 25 | 1.3.3.4 | Team feedback | manual | 2d | 2013-02-01 | 2013-02-04 |  |  |  |  |  |  |

| ID | WBS | Task | Type | Duration | Start | Finish | Predecessors | Complete | Remaining | Total slack | Free slack | Resources | Work | Actual work |
| --- | --- | --- | --- | --- | --- | --- | --- | --- | --- | --- | --- | --- | --- | --- |
| 26 | 1.3.4 | **Analyze Recommendation and Solution** |  | 70d | 2012-11-14 A | 2013-02-19 |  | 20% | 56d | 0d |  |  | 8h | 8h |
| 27 | 1.3.4.1 | Peer school comparion breakdown | manual | 1d | 2012-11-14 A | 2012-11-14 A |  | 100% |  |  |  | Andrew | 8h | 8h |
| 28 | 1.3.4.2 | Determine any contract/licensing issues | manual | 1d | 2013-02-15 | 2013-02-15 | 24 |  |  |  |  |  |  |  |
| 29 | 1.3.4.3 | Determine total cost of ownership |  | 1d | 2013-02-15 | 2013-02-15 | 24 |  |  | 0d |  |  |  |  |
| 30 | 1.3.4.4 | Determine benefits and concerns |  | 1d | 2013-02-18 | 2013-02-18 | 29 |  |  | 0d |  |  |  |  |
| 31 | 1.3.4.5 | Determine support process/structure |  | 1d | 2013-02-19 | 2013-02-19 | 30 |  |  | 0d |  |  |  |  |
| 32 | 1.3.5 | **Sponsor approval** |  | 5d | 2013-02-19 | 2013-02-26 | 26 |  |  |  |  |  |  |  |
| 33 | 1.3.5.1 | Approval from sponsor | manual | 1d? | 2013-02-19 | 2013-02-20 |  |  |  |  |  |  |  |  |
| 34 | 1.3.6 | **McAfee License** |  | 76d? | 2012-11-14 A | 2013-02-27 |  | 50% | 38d? | 27d |  |  |  |  |
| 35 | 1.3.6.1 | Understand current McAfee license constraints |  | 1d | 2012-11-14 A | 2012-11-14 A |  | 100% |  |  |  |  |  |  |
| 36 | 1.3.6.2 | Adjust McAfee license based on new requirements |  | 1d? | 2013-02-27 | 2013-02-27 | 32 |  |  | 27d |  |  |  |  |
| 37 | 1.3.7 | **Documentation and communication** |  | 1d? | 2013-02-27 | 2013-02-27 | 32 |  |  | -15d | 0d |  |  |  |
| 38 | 1.3.7.1 | Helpdesk (awareness only) |  | 1d? | 2013-02-27 | 2013-02-27 |  |  |  | 27d |  |  |  |  |
| 39 | 1.3.7.2 | DITR (awareness only) |  | 1d? | 2013-02-27 | 2013-02-27 |  |  |  | 27d |  |  |  |  |
| 40 | 1.3.7.3 | ITLEADERS (awareness and preparing for early adaptors only) |  | 1d? | 2013-02-27 | 2013-02-27 |  |  |  | -15d | 0d |  |  |  |
| 41 | 1.3.8 | **Pilot rollout (STAKEHOLDERS)** |  | 10d | 2013-02-26 | 2013-03-12 | 32 |  |  |  |  |  |  |  |
| 42 | 1.3.8.1 | Determine pilot rollout team | manual | 1d? | 2013-02-26 | 2013-02-27 |  |  |  |  |  |  |  |  |
| 43 | 1.3.8.2 | Determine timelines | manual | 1d? | 2013-02-26 | 2013-02-27 |  |  |  |  |  |  |  |  |
| 44 | 1.3.8.3 | determine pilot rollout strategy | manual | 1d? | 2013-02-26 | 2013-02-27 |  |  |  |  |  |  |  |  |
| 45 | 1.3.8.4 | Collect feedback | manual | 1d? | 2013-02-26 | 2013-02-27 |  |  |  |  |  |  |  |  |
| 46 | 1.3.8.5 | Checkpoint: Present pilot rollout feedback to Sponsor | manual | 1d? | 2013-02-26 | 2013-02-27 |  |  |  |  |  |  |  |  |
| 47 | 1.3.9 | **Procurement** |  | 10d | 2013-03-12 | 2013-03-26 | 41 |  |  |  |  |  |  |  |
| 48 | 1.3.9.1 | Negotiate pricing | manual | 1d? | 2013-03-12 | 2013-03-13 |  |  |  |  |  |  |  |  |
| 49 | 1.3.9.2 | Contract agreement and signature | manual | 1d? | 2013-03-12 | 2013-03-13 |  |  |  |  |  |  |  |  |
| 50 | 1.3.9.3 | Purchase | manual | 1d? | 2013-03-12 | 2013-03-13 |  |  |  |  |  |  |  |  |
| 51 | 1.3.9.4 | Reminder: adjust McAfee contract | manual | 1d? | 2013-03-12 | 2013-03-13 |  |  |  |  |  |  |  |  |

| ID | WBS | Task | Type | Duration | Start | Finish | Predecessors | Complete | Remaining | Total slack | Resources | Work | Actual work |
| --- | --- | --- | --- | --- | --- | --- | --- | --- | --- | --- | --- | --- | --- |
| 52 | 1.3.10 | **EARLY ADOPTERS** |  | 10d | 2013-03-12 | 2013-03-26 | 41 |  |  |  |  |  |  |
| 53 | 1.3.10.1 | Determine early adopters participants | manual | 1d? | 2013-03-12 | 2013-03-13 |  |  |  |  |  |  |  |
| 54 | 1.3.10.2 | Determine timelines | manual | 1d? | 2013-03-12 | 2013-03-13 |  |  |  |  |  |  |  |
| 55 | 1.3.10.3 | determine beta rollout strategy | manual | 1d? | 2013-03-12 | 2013-03-13 |  |  |  |  |  |  |  |
| 56 | 1.3.10.4 | collect feedback | manual | 1d? | 2013-03-12 | 2013-03-13 |  |  |  |  |  |  |  |
| 57 | 1.3.11 | Final Checkpoint: Present all feedback including beta rollout feedback to Sponsor |  | 1d? | 2012-11-14 | 2012-11-14 |  |  |  | 102d |  |  |  |
| 58 | 1.3.12 | **General Communications** |  | 2d | 2013-03-26 | 2013-03-28 | 52 |  |  |  |  |  |  |
| 59 | 1.3.12.1 | to community | manual | 1d? | 2013-03-26 | 2013-03-27 |  |  |  |  |  |  |  |
| 60 | 1.3.13 | **Prep Helpdesk for full rollout support** |  | 5d | 2013-03-28 | 2013-04-04 | 58 |  |  |  |  |  |  |
| 61 | 1.3.13.1 | any additional training/documentation | manual | 1d? | 2013-03-28 | 2013-03-29 |  |  |  |  |  |  |  |
| 62 | 1.3.14 | **Full rollout (COMMUNITY)** |  | 1d | 2013-04-04 | 2013-04-05 | 60 |  |  |  |  |  |  |
| 63 | 1.3.14.1 | Provide software to SWRT for distribution | manual | 1d? | 2013-04-04 | 2013-04-05 |  |  |  |  |  |  |  |
| 64 | 1.4 | **MAC Selection** |  | 101d? | 2012-11-14 A | 2013-04-03 |  | 16% | 85.16d? | 0d |  | 672h | 12.4h |
| 65 | 1.4.1 | **Evaluation** |  | 47d? | 2012-11-28 A | 2013-01-31 |  | 75% | 11.75d? | 0d |  | 672h | 12.4h |
| 66 | 1.4.1.1 | **Sophos Evaluation** |  | 47d? | 2012-11-28 A | 2013-01-31 |  | 75% | 11.75d? | 0d | Andrew | 336h | 6.4h |
| 67 | 1.4.1.1.1 | VM setup | manual | 1d | 2012-11-28 A | 2012-11-28 A |  | 100% |  |  |  |  |  |
| 68 | 1.4.1.1.2 | Console setup | manual | 1d | 2012-12-05 A | 2012-12-05 A |  | 100% |  |  |  |  |  |
| 69 | 1.4.1.1.3 | Console and client functionality evaluation | manual | 1d | 2012-11-28 A | 2012-11-28 A |  | 100% |  |  |  |  |  |
| 70 | 1.4.1.1.4 | Document Pros and cons | manual | 1d? | 2013-01-31 | 2013-01-31 |  |  |  |  |  |  |  |
| 71 | 1.4.1.2 | **ESET Evaluation (v5.0 - Jan 2013)** |  | 42d? | 2012-12-05 A | 2013-01-31 |  | 75% | 10.5d? | 0d | Andrew | 336h | 6h |
| 72 | 1.4.1.2.1 | VM setup | manual | 1d | 2012-12-05 A | 2012-12-05 A |  | 100% |  |  |  |  |  |
| 73 | 1.4.1.2.2 | Console setup | manual | 1d | 2012-12-05 A | 2012-12-05 A |  | 100% |  |  |  |  |  |
| 74 | 1.4.1.2.3 | Console and client functionality evaluation | manual | 1d | 2012-12-05 A | 2012-12-05 A |  | 100% |  |  |  |  |  |
| 75 | 1.4.1.2.4 | Document pros and cons | manual | 1d? | 2013-01-31 | 2013-01-31 |  |  |  |  |  |  |  |

| ID | WBS | Task | Type | Duration | Start | Finish | Predecessors | Complete | Remaining | Total slack |
| --- | --- | --- | --- | --- | --- | --- | --- | --- | --- | --- |
| 76 | 1.4.2 | **Vendor Demo** |  | 59d? | 2012-11-14 A | 2013-02-04 |  | 40% | 35.4d? | 0d |
| 77 | 1.4.2.1 | Determine which vendor(s) to demo | manual | 1d | 2012-11-14 A | 2012-11-14 A |  | 100% |  |  |
| 78 | 1.4.2.2 | Determine invitees | manual | 1d | 2012-11-14 A | 2012-11-14 A |  | 100% |  |  |
| 79 | 1.4.2.3 | Determine requirements | manual | 1d? | 2013-02-01 | 2013-02-01 |  |  |  |  |
| 80 | 1.4.2.4 | Demo | manual | 1d? | 2013-02-01 | 2013-02-01 |  |  |  |  |
| 81 | 1.4.2.5 | Team feedback | manual | 1d | 2013-02-04 | 2013-02-04 | 80 |  |  |  |
| 82 | 1.4.3 | **Analyze Recommendation and Solution** |  | 2d | 2013-02-07 | 2013-02-08 |  |  |  | 0d |
| 83 | 1.4.3.1 | Determine any contract/licensing issues | manual | 2d | 2013-02-07 | 2013-02-08 | 40 |  |  |  |
| 84 | 1.4.3.2 | Determine total cost of ownership | manual | 2d | 2013-02-07 | 2013-02-08 | 40 |  |  |  |
| 85 | 1.4.3.3 | Determine benefits and concerns | manual | 2d | 2013-02-07 | 2013-02-08 | 40 |  |  |  |
| 86 | 1.4.3.4 | Determine support process/structure | manual | 2d | 2013-02-07 | 2013-02-08 | 40 |  |  |  |
| 87 | 1.4.4 | **Sponsor approval** |  | 5d | 2013-02-08 | 2013-02-15 | 82 |  |  |  |
| 88 | 1.4.4.1 | Approval from sponsor | manual | 1d? | 2013-02-08 | 2013-02-11 |  |  |  |  |
| 89 | 1.4.5 | **Documentation and communication** |  | 3d | 2013-02-18 | 2013-02-20 | 87 |  |  | 0d |
| 90 | 1.4.5.1 | Helpdesk (awareness only) | manual | 1d | 2013-02-18 | 2013-02-18 | 87 |  |  |  |
| 91 | 1.4.5.2 | DITR (awareness only) | manual | 1d | 2013-02-19 | 2013-02-19 | 90 |  |  |  |
| 92 | 1.4.5.3 | ITLEADERS (awareness and preparing for early adaptors only) | manual | 1d | 2013-02-20 | 2013-02-20 | 91 |  |  |  |
| 93 | 1.4.6 | **Pilot rollout (STAKEHOLDERS)** |  | 5d | 2013-02-18 | 2013-02-22 |  |  |  | 0d |
| 94 | 1.4.6.1 | Determine pilot rollout team | manual | 1d | 2013-02-18 | 2013-02-18 | 87 |  |  |  |
| 95 | 1.4.6.2 | Determine timelines | manual | 1d | 2013-02-20 | 2013-02-20 | 94 |  |  |  |
| 96 | 1.4.6.3 | determine pilot rollout strategy | manual | 1d | 2013-02-21 | 2013-02-21 | 95 |  |  |  |
| 97 | 1.4.6.4 | Collect feedback | manual | 1d | 2013-02-22 | 2013-02-22 | 96 |  |  |  |
| 98 | 1.4.7 | **Procurement** |  | 10d | 2013-02-22 | 2013-03-08 | 93 |  |  |  |
| 99 | 1.4.7.1 | Negotiate pricing | manual | 1d? | 2013-02-22 | 2013-02-25 |  |  |  |  |
| 100 | 1.4.7.2 | Contract agreement and signature | manual | 1d? | 2013-02-22 | 2013-02-25 |  |  |  |  |
| 101 | 1.4.7.3 | Purchase | manual | 1d? | 2013-02-22 | 2013-02-25 |  |  |  |  |
| 102 | 1.4.7.4 | Reminder: adjust McAfee contract | manual | 1d? | 2013-02-22 | 2013-02-25 |  |  |  |  |

| ID | WBS | Task | Type | Duration | Start | Finish | Predecessors | Total slack |
| --- | --- | --- | --- | --- | --- | --- | --- | --- |
| 103 | 1.4.8 | **EARLY ADOPTERS** |  | 13d | 2013-03-11 | 2013-03-27 | 98 | 0d |
| 104 | 1.4.8.1 | Determine early adopters participants | manual | 1d | 2013-03-11 | 2013-03-11 | 98 |  |
| 105 | 1.4.8.2 | Determine timelines | manual | 1d | 2013-03-12 | 2013-03-12 | 104 |  |
| 106 | 1.4.8.3 | determine beta rollout strategy | manual | 1d | 2013-03-13 | 2013-03-13 | 105 |  |
| 107 | 1.4.8.4 | collect feedback | manual | 10d | 2013-03-14 | 2013-03-27 | 106 |  |
| 108 | 1.4.9 | Final Checkpoint: Present all feedback including beta rollout feedback to Sponsor | manual | 1d? | 2013-03-28 | 2013-03-28 | 106 |  |
| 109 | 1.4.10 | **General Communications** |  | 1d | 2013-03-28 | 2013-03-29 | 108 |  |
| 110 | 1.4.10.1 | to community | manual | 1d? | 2013-03-28 | 2013-03-29 |  |  |
| 111 | 1.4.11 | **Prep Helpdesk for full rollout support** |  | 2d | 2013-04-01 | 2013-04-02 | 109 | 0d |
| 112 | 1.4.11.1 | any additional training/documentation | manual | 2d | 2013-04-01 | 2013-04-02 | 109 |  |
| 113 | 1.4.12 | **Full rollout (COMMUNITY)** |  | 1d | 2013-04-02 | 2013-04-03 | 111 |  |
| 114 | 1.4.12.1 | Provide software to SWRT for distribution | manual | 1d | 2013-04-03 | 2013-04-03 | 111 |  |
| 115 | 1.5 | **Project Wrapup** |  | 1d? | 2013-04-03 | 2013-04-04 | 113 | 0d |
| 116 | 1.5.1 | closeout project | manual | 1d? | 2013-04-03 | 2013-04-04 |  |  |
