# Malware Protection Overhaul May09

Schedule from MS Project, 2012-11-05 to 2013-06-18, A marks actual dates.
MIT

## Calendars

- Standard: Mon-Fri 08:00-12:00, 13:00-17:00; Sat-Sun off.

## Resources

| Resource |
| --- |
| Andrew |
| Sophie |
| Richard |
| Tim |

## Schedule

| ID | WBS | Task | Type | Duration | Start | Finish | Complete | Remaining | Total slack | Resources | Work | Actual work |
| --- | --- | --- | --- | --- | --- | --- | --- | --- | --- | --- | --- | --- |
| 1 | 1 | **Malware Protection Overhaul Project** |  | 162d? | 2012-11-05 A | 2013-06-18 | 55% | 72.58d? | 0d |  | 3368.8h | 1219.6h |
| 2 | 1.1 | **Planning** |  | 1d | 2012-11-05 A | 2012-11-05 A | 100% |  |  |  | 24h | 24h |
| 3 | 1.1.1 | Define scope | manual | 1d | 2012-11-05 A | 2012-11-05 A | 100% |  |  | Sophie | 8h | 8h |
| 4 | 1.1.2 | Review scope with Mark | manual | 1d | 2012-11-05 A | 2012-11-05 A | 100% |  |  | Sophie | 8h | 8h |
| 5 | 1.1.3 | Kickoff Meeting - include other teams | manual | 1d | 2012-11-05 A | 2012-11-05 A | 100% |  |  | Sophie | 8h | 8h |
| 6 | 1.2 | **Communications** |  | 1d? | 2012-11-14 A | 2012-11-14 A | 100% |  |  |  | 24h | 24h |
| 7 | 1.2.1 | Initial IT Leader meeting presentation |  | 1d? | 2012-11-14 A | 2012-11-14 A | 100% |  |  | Andrew | 8h | 8h |
| 8 | 1.2.2 | Contact IT Leaders to solicite volunteers for pilot | manual | 1d | 2012-11-14 A | 2012-11-14 A | 100% |  |  | Tim | 8h | 8h |
| 9 | 1.2.3 | Checklist for pilot | manual | 1d | 2012-11-14 A | 2012-11-14 A | 100% |  |  | Andrew | 8h | 8h |
| 10 | 1.3 | **Vendor Selection** |  | 126d | 2012-11-14 A | 2013-05-08 A | 100% |  |  |  | 1160h | 1160h |
| 11 | 1.3.1 | **Sophos Evaluation** |  | 47d | 2012-11-28 A | 2013-01-31 A | 100% |  |  | Andrew | 336h | 336h |
| 12 | 1.3.1.1 | VM setup | manual | 1d | 2012-11-28 A | 2012-11-28 A | 100% |  |  |  |  |  |
| 13 | 1.3.1.2 | Console setup | manual | 1d | 2012-12-05 A | 2012-12-05 A | 100% |  |  |  |  |  |
| 14 | 1.3.1.3 | Console and client functionality evaluation | manual | 1d | 2012-11-28 A | 2012-11-28 A | 100% |  |  |  |  |  |
| 15 | 1.3.1.4 | Document Pros and cons | manual | 1d | 2013-01-31 A | 2013-01-31 A | 100% |  |  |  |  |  |
| 16 | 1.3.2 | **ESET Evaluation (v5.0 - Jan 2013)** |  | 42d | 2012-12-05 A | 2013-01-31 A | 100% |  |  | Andrew | 336h | 336h |
| 17 | 1.3.2.1 | VM setup | manual | 1d | 2012-12-05 A | 2012-12-05 A | 100% |  |  |  |  |  |
| 18 | 1.3.2.2 | Console setup | manual | 1d | 2012-12-05 A | 2012-12-05 A | 100% |  |  |  |  |  |
| 19 | 1.3.2.3 | Console and client functionality evaluation | manual | 1d | 2012-12-05 A | 2012-12-05 A | 100% |  |  |  |  |  |
| 20 | 1.3.2.4 | Document pros and cons | manual | 1d | 2013-01-31 A | 2013-01-31 A | 100% |  |  |  |  |  |
| 21 | 1.3.3 | **System Center 2012 (Forefront) Evaluation** |  | 57d | 2012-11-14 A | 2013-01-31 A | 100% |  |  | Andrew | 472h | 472h |
| 22 | 1.3.3.1 | VM setup | manual | 1d | 2012-11-14 A | 2012-11-14 A | 100% |  |  | Richard | 8h | 8h |
| 23 | 1.3.3.2 | Console setup | manual | 1d | 2012-11-14 A | 2012-11-14 A | 100% |  |  | Richard | 8h | 8h |
| 24 | 1.3.3.3 | Console and client functionality evaluation | manual | 1d | 2013-01-31 A | 2013-01-31 A | 100% |  |  |  |  |  |

| ID | WBS | Task | Type | Duration | Start | Finish | Predecessors | Complete | Remaining | Actual start | Actual finish | Total slack | Resources | Work | Actual work |
| --- | --- | --- | --- | --- | --- | --- | --- | --- | --- | --- | --- | --- | --- | --- | --- |
| 25 | 1.3.4 | **ESET Evaluation (v5.0 - Jan 2013)** |  | 1d | 2012-11-14 A | 2012-11-14 A |  | 100% |  |  |  |  | Andrew | 8h | 8h |
| 26 | 1.3.4.1 | VM setup | manual | 1d | 2012-11-14 A | 2012-11-14 A |  | 100% |  |  |  |  |  |  |  |
| 27 | 1.3.4.2 | Console setup | manual | 1d | 2012-11-14 A | 2012-11-14 A |  | 100% |  |  |  |  |  |  |  |
| 28 | 1.3.4.3 | Console and client functionality evaluation | manual | 1d | 2012-11-14 A | 2012-11-14 A |  | 100% |  |  |  |  |  |  |  |
| 29 | 1.3.5 | **Vendor Demo** |  | 67d | 2012-11-14 A | 2013-02-14 A |  | 100% |  |  |  |  |  |  |  |
| 30 | 1.3.5.1 | Determine invitees | manual | 1d | 2012-11-14 A | 2012-11-14 A |  | 100% |  |  |  |  |  |  |  |
| 31 | 1.3.5.2 | Determine requirements | manual | 1d | 2013-02-01 A | 2013-02-01 A |  | 100% |  |  |  |  |  |  |  |
| 32 | 1.3.5.3 | Demo | manual | 10d | 2013-02-01 A | 2013-02-14 A |  | 100% |  |  |  |  |  |  |  |
| 33 | 1.3.5.4 | Team feedback | manual | 2d | 2013-02-01 A | 2013-02-04 A |  | 100% |  |  |  |  |  |  |  |
| 34 | 1.3.6 | **Analyze Recommendation and Solution** |  | 70d | 2012-11-14 A | 2013-02-19 A |  | 100% |  |  |  |  |  | 8h | 8h |
| 35 | 1.3.6.1 | Peer school comparion breakdown | manual | 1d | 2012-11-14 A | 2012-11-14 A |  | 100% |  |  |  |  | Andrew | 8h | 8h |
| 36 | 1.3.6.2 | Determine any contract/licensing issues | manual | 1d | 2013-02-15 A | 2013-02-15 A | 32 | 100% |  |  |  |  |  |  |  |
| 37 | 1.3.6.3 | Determine total cost of ownership |  | 1d | 2013-02-15 A | 2013-02-15 A | 32 | 100% |  |  |  |  |  |  |  |
| 38 | 1.3.6.4 | Determine benefits and concerns |  | 1d | 2013-02-18 A | 2013-02-18 A | 37 | 100% |  |  |  |  |  |  |  |
| 39 | 1.3.6.5 | Determine support process/structure |  | 1d | 2013-02-19 A | 2013-02-19 A | 38 | 100% |  |  |  |  |  |  |  |
| 40 | 1.3.7 | **Sponsor approval** |  | 5d | 2013-02-19 | 2013-02-26 | 34 | 100% |  | 2013-05-08 | 2013-05-08 |  |  |  |  |
| 41 | 1.3.7.1 | Approval from sponsor | manual | 1d | 2013-05-08 A | 2013-05-08 A |  | 100% |  |  |  |  |  |  |  |
| 42 | 1.4 | **McAfee License** |  | 126d? | 2012-11-14 A | 2013-05-08 |  | 50% | 63d? |  |  | 29d | Sophie | 1008h | 8h |
| 43 | 1.4.1 | Understand current McAfee license constraints |  | 1d | 2012-11-14 A | 2012-11-14 A |  | 100% |  |  |  |  |  |  |  |
| 44 | 1.4.2 | Understand what the license needs are | manual | 1d | 2013-05-08 A | 2013-05-08 |  | 50% | 0.5d |  |  |  |  |  |  |
| 45 | 1.4.3 | Adjust McAfee license based on new requirements |  | 1d? | 2013-02-27 | 2013-02-27 | 40 |  |  |  |  | 79d |  |  |  |
| 46 | 1.5 | **Documentation and communication** |  | 1d? | 2013-05-09 | 2013-05-09 | 41 |  |  |  |  | 28d | Sophie | 8h |  |
| 47 | 1.5.1 | Helpdesk (awareness only) |  | 1d? | 2013-05-09 | 2013-05-09 |  |  |  |  |  | 28d |  |  |  |
| 48 | 1.5.2 | DITR (awareness only) |  | 1d? | 2013-05-09 | 2013-05-09 |  |  |  |  |  | 28d |  |  |  |
| 49 | 1.5.3 | ITLEADERS (awareness and preparing for early adaptors only) |  | 1d? | 2013-05-09 | 2013-05-09 |  |  |  |  |  | 28d |  |  |  |

| ID | WBS | Task | Type | Duration | Start | Finish | Predecessors | Complete | Remaining | Total slack | Free slack | Constraint | Resources | Work | Actual work |
| --- | --- | --- | --- | --- | --- | --- | --- | --- | --- | --- | --- | --- | --- | --- | --- |
| 50 | 1.6 | **Full Integration Testing** |  | 10d | 2013-02-26 | 2013-03-12 |  |  |  |  |  |  |  |  |  |
| 51 | 1.6.1 | Setup |  | 2d | 2013-05-09 | 2013-05-10 |  |  |  | 27d |  | start no earlier than 2013-05-09 |  |  |  |
| 52 | 1.6.2 | Determine pilot rollout team |  | 1d? | 2013-05-09 | 2013-05-09 |  |  |  | 28d |  | start no earlier than 2013-05-09 |  |  |  |
| 53 | 1.6.3 | Determine timelines |  | 1d? | 2013-05-09 | 2013-05-09 | 41 |  |  | -42d | 0d |  |  |  |  |
| 54 | 1.6.4 | determine pilot rollout strategy |  | 1d? | 2013-05-09 | 2013-05-09 | 41 |  |  | -56d | 0d |  |  |  |  |
| 55 | 1.6.5 | Pilot rollout (STAKEHOLDERS) |  | 10d | 2013-05-10 | 2013-05-23 | 54 |  |  | -56d | 0d |  |  |  |  |
| 56 | 1.6.6 | Collect feedback |  | 1d? | 2013-05-24 | 2013-05-24 | 55 |  |  | -56d | 0d |  |  |  |  |
| 57 | 1.6.7 | Checkpoint: Present feedback to Sponsor |  | 3d | 2013-05-27 | 2013-05-29 | 56 |  |  | -56d | 0d |  |  |  |  |
| 58 | 1.7 | **Procurement** |  | 17d? | 2013-05-09 | 2013-05-31 |  |  |  | 12d |  |  |  | 8h |  |
| 59 | 1.7.1 | Negotiate pricing |  | 1d? | 2013-05-09 | 2013-05-09 | 41 |  |  | 28d |  |  | Sophie | 8h |  |
| 60 | 1.7.2 | Contract agreement and signature |  | 1d? | 2013-05-30 | 2013-05-30 | 57 |  |  | 12d | 0d |  |  |  |  |
| 61 | 1.7.3 | Purchase |  | 1d? | 2013-05-31 | 2013-05-31 | 60 |  |  | 12d |  |  |  |  |  |
| 62 | 1.7.4 | Reminder: adjust McAfee contract |  | 1d? | 2013-05-31 | 2013-05-31 | 60 |  |  | 12d |  |  |  |  |  |
| 63 | 1.8 | **communicate new solution deployment and maintenance to impacted stakeholders** |  | 142.1d? | 2012-11-14 A | 2013-05-31 |  | 50% | 71.05d? | 0d |  |  | Sophie | 1136.8h | 3.6h |
| 64 | 1.8.1 | identify current teams impacted by this change & communicate to them new product and new maintenance structure |  | 1d | 2012-11-14 A | 2013-05-31 A | 60 | 100% |  |  |  |  |  |  |  |
| 65 | 1.8.2 | planning meeting | manual | 1d? | 2012-11-14 | 2012-11-14 |  |  |  |  |  |  |  |  |  |
| 66 | 1.9 | **Setup for distribution** |  | 1d? | 2013-05-31 | 2013-06-03 |  |  |  | 7.9d | 0d |  |  |  |  |
| 67 | 1.9.1 | Assist teams in setting up for distribution |  | 1d? | 2013-05-31 | 2013-06-03 | 64 |  |  | 7.9d |  |  |  |  |  |
| 68 | 1.10 | **General Communications** |  | 8.9d? | 2013-06-03 | 2013-06-13 | 66 |  |  | 0d |  |  |  |  |  |
| 69 | 1.10.1 | to community |  | 1d? | 2013-06-03 | 2013-06-04 |  |  |  | 7.9d |  |  |  |  |  |
| 70 | 1.10.2 | IT Partners presentation |  | 1d? | 2013-06-13 | 2013-06-13 |  |  |  | 0d |  | start no earlier than 2013-06-13 |  |  |  |
| 71 | 1.11 | **Prep Helpdesk for full rollout support** |  | 1d? | 2013-06-14 | 2013-06-14 | 68 |  |  | 0d |  |  |  |  |  |
| 72 | 1.11.1 | any additional training/documentation |  | 1d? | 2013-06-14 | 2013-06-14 |  |  |  | 0d |  |  |  |  |  |
| 73 | 1.12 | **Full rollout (COMMUNITY)** |  | 1d? | 2013-06-17 | 2013-06-17 | 72 |  |  | 0d |  |  |  |  |  |
| 74 | 1.12.1 | Provide software to SWRT for distribution |  | 1d? | 2013-06-17 | 2013-06-17 | 72 |  |  | 0d |  |  |  |  |  |

| ID | WBS | Task | Type | Duration | Start | Finish | Predecessors | Total slack |
| --- | --- | --- | --- | --- | --- | --- | --- | --- |
| 75 | 1.13 | **Project Wrapup** |  | 1d? | 2013-06-18 | 2013-06-18 | 74 | 0d |
| 76 | 1.13.1 | closeout project |  | 1d? | 2013-06-18 | 2013-06-18 |  | 0d |
| 77 | 2 | Post project support | milestone, manual | 0d | 2013-06-17 | 2013-06-17 | 71 |  |
